# Enc-01-01

How a schedule from MS Project changed from version to version. A marks actual dates.

## Version 1 (saved 2007-06-30, file Enc-03-01.mpp)

| ID | Task | Duration | Start | Finish | Total float |
| --- | --- | --- | --- | --- | --- |
| 1 | koncepce vybavení místnosti | 1w | 2008-03-31 | 2008-04-03 | 8.75d |
| 2 | rozpočet vybavení místnosti | 2d | 2008-03-31 | 2008-04-01 | 9d |
| 3 | schválení koncepce a rozpočtu vybavení | 1d | 2008-03-31 | 2008-03-31 | 10d |
| 4 | výběr a objednání počítačů | 3d | 2008-03-31 | 2008-04-02 | 8d |
| 5 | dodání počítačů a dataprojektoru | 1d | 2008-03-31 | 2008-03-31 | 10d |
| 6 | zazdění dveří | 2d | 2008-03-31 | 2008-04-01 | 9d |
| 7 | podhled | 2d | 2008-03-31 | 2008-04-01 | 9d |
| 8 | elektroinstalace | 1d | 2008-03-31 | 2008-03-31 | 10d |
| 9 | vymalování | 1d | 2008-03-31 | 2008-03-31 | 10d |
| 10 | položení koberce | 1d | 2008-03-31 | 2008-03-31 | 10d |
| 11 | výběr a objednání nábytku | 3d | 2008-03-31 | 2008-04-02 | 8d |
| 12 | dodání a montáž nábytku | 1d | 2008-03-31 | 2008-03-31 | 10d |
| 13 | vyvětrání | 5ed | 2008-03-31 | 2008-04-05 | 30d |
| 14 | instalace sítě | 1d | 2008-03-31 | 2008-03-31 | 10d |
| 15 | instalace počítačů | 1d | 2008-03-31 | 2008-03-31 | 10d |
| 16 | příprava rezervačního software | 5d | 2008-03-31 | 2008-04-04 | 6d |
| 17 | zahájení provozu místnosti | 0d | 2008-03-31 | 2008-03-31 | 11d |
| 18 | webová prezentace uvedení | 2d | 2008-03-31 | 2008-04-01 | 9d |
| 19 | přihlašování na uvedení | 15ed | 2008-03-31 | 2008-04-15 | 0d |
| 20 | objednání občerstvení | 1d | 2008-03-31 | 2008-03-31 | 10d |
| 21 | návrh letáků k uvedení | 2d | 2008-03-31 | 2008-04-01 | 9d |
| 22 | dodání letáků | 0d | 2008-03-31 | 2008-03-31 | 11d |
| 23 | rozeslání pozvánek | 2d | 2008-03-31 | 2008-04-01 | 9d |
| 24 | výběr, objednání propagačních materiálů | 1d | 2008-03-31 | 2008-03-31 | 10d |
| 25 | dodání propagačních materiálů | 0d | 2008-03-31 | 2008-03-31 | 11d |
| 26 | milník přípravy akce uvedení | 0d | 2008-03-31 | 2008-03-31 | 11d |
| 27 | uzávěrka přihlašování | 0d | 2008-03-31 | 2008-03-31 | 11d |
| 28 | průběh akce uvedení software | 1d | 2008-03-31 | 2008-03-31 | 10d |
| 29 | tisková zpráva o uvedení | 1d | 2008-03-31 | 2008-03-31 | 10d |

## Version 2 (saved 2007-06-30, file Enc-03-03.mpp)

Last finish 2008-04-15 → 2008-06-25 (+71d).

Changed:

| ID | Task | Start | Finish | Total float | Predecessors | Other |
| --- | --- | --- | --- | --- | --- | --- |
| 1 | koncepce vybavení místnosti | 2008-03-31 → 2008-04-04 (+4d) | 2008-04-03 → 2008-04-09 (+6d) | 8.75d → 0d |  |  |
| 2 | rozpočet vybavení místnosti | 2008-03-31 → 2008-04-08 (+8d) | 2008-04-01 → 2008-04-09 (+8d) | 9d → 0d | none → 1SS+2d |  |
| 3 | schválení koncepce a rozpočtu vybavení | 2008-03-31 → 2008-04-10 (+10d) | 2008-03-31 → 2008-04-10 (+10d) | 10d → 0d | none → 1, 2 |  |
| 4 | výběr a objednání počítačů | 2008-03-31 → 2008-04-11 (+11d) | 2008-04-02 → 2008-04-15 (+13d) | 8d → 10d | none → 3 |  |
| 5 | dodání počítačů a dataprojektoru | 2008-03-31 → 2008-04-30 (+30d) | 2008-03-31 → 2008-04-30 (+30d) |  | none → 4FS+2w |  |
| 6 | zazdění dveří | 2008-03-31 → 2008-04-11 (+11d) | 2008-04-01 → 2008-04-14 (+13d) | 9d → 11d | none → 3 |  |
| 7 | podhled | 2008-03-31 → 2008-04-15 (+15d) | 2008-04-01 → 2008-04-16 (+15d) | 9d → 11d | none → 6 |  |
| 8 | elektroinstalace | 2008-03-31 → 2008-04-17 (+17d) | 2008-03-31 → 2008-04-17 (+17d) | 10d → 11d | none → 7 |  |
| 9 | vymalování | 2008-03-31 → 2008-04-18 (+18d) | 2008-03-31 → 2008-04-18 (+18d) | 10d → 11d | none → 8 |  |
| 10 | položení koberce | 2008-03-31 → 2008-04-21 (+21d) | 2008-03-31 → 2008-04-21 (+21d) | 10d → 11d | none → 9 |  |
| 11 | výběr a objednání nábytku | 2008-03-31 → 2008-04-11 (+11d) | 2008-04-02 → 2008-04-15 (+13d) | 8d → 0d | none → 3 |  |
| 12 | dodání a montáž nábytku | 2008-03-31 → 2008-05-09 (+39d) | 2008-03-31 → 2008-05-09 (+39d) | 10d → 0d | none → 10, 11FS+3w |  |
| 13 | vyvětrání | 2008-03-31 → 2008-05-09 (+39d) | 2008-04-05 → 2008-05-14 (+39d) | 30d → 4.88d | none → 12 |  |
| 14 | instalace sítě | 2008-03-31 → 2008-05-15 (+45d) | 2008-03-31 → 2008-05-15 (+45d) | 10d → 1d | none → 13 |  |
| 15 | instalace počítačů | 2008-03-31 → 2008-05-16 (+46d) | 2008-03-31 → 2008-05-16 (+46d) | 10d → 1d | none → 14, 5 |  |
| 16 | příprava rezervačního software | 2008-03-31 → 2008-04-04 (+4d) | 2008-04-04 → 2008-04-10 (+6d) | 6d → 25d |  |  |
| 17 | zahájení provozu místnosti | 2008-03-31 → 2008-05-16 (+46d) | 2008-03-31 → 2008-05-16 (+46d) | 11d → 1d | none → 16, 15 |  |
| 18 | webová prezentace uvedení | 2008-03-31 → 2008-05-19 (+49d) | 2008-04-01 → 2008-05-20 (+49d) | 9d → 1d | none → 17 |  |
| 19 | přihlašování na uvedení | 2008-03-31 → 2008-06-03 (+64d) | 2008-04-15 → 2008-06-18 (+64d) | 0d → 4.88d | none → 18FS+2w |  |
| 20 | objednání občerstvení | 2008-03-31 → 2008-04-11 (+11d) | 2008-03-31 → 2008-04-11 (+11d) | 10d → 39d | none → 3 |  |
| 21 | návrh letáků k uvedení | 2008-03-31 → 2008-04-11 (+11d) | 2008-04-01 → 2008-04-14 (+13d) | 9d → 40d | none → 3 |  |
| 22 | dodání letáků | 2008-03-31 → 2008-04-14 (+14d) | 2008-03-31 → 2008-04-14 (+14d) | 11d → 40d | none → 21 |  |
| 23 | rozeslání pozvánek | 2008-03-31 → 2008-04-15 (+15d) | 2008-04-01 → 2008-04-16 (+15d) | 9d → 47d | none → 22 |  |
| 24 | výběr, objednání propagačních materiálů | 2008-03-31 → 2008-04-11 (+11d) | 2008-03-31 → 2008-04-11 (+11d) | 10d → 39d | none → 3 |  |
| 25 | dodání propagačních materiálů | 2008-03-31 → 2008-04-11 (+11d) | 2008-03-31 → 2008-04-11 (+11d) | 11d → 39d | none → 24 |  |
| 26 | milník přípravy akce uvedení | 2008-03-31 → 2008-04-18 (+18d) | 2008-03-31 → 2008-04-18 (+18d) | 11d → 39d | none → 25FS+5d, 22FS+3d |  |
| 27 | uzávěrka přihlašování | 2008-03-31 → 2008-06-18 (+79d) | 2008-03-31 → 2008-06-18 (+79d) | 11d → 1d | none → 19 |  |
| 28 | průběh akce uvedení software | 2008-03-31 → 2008-06-24 (+85d) | 2008-03-31 → 2008-06-24 (+85d) | 10d → 0d | none → 26FS+1w, 20FS+10d, 27FS+2d | constraint none → must start on 2008-06-24 |
| 29 | tisková zpráva o uvedení | 2008-03-31 → 2008-06-25 (+86d) | 2008-03-31 → 2008-06-25 (+86d) | 10d → 0d | none → 28, 23 |  |

## Version 3 (saved 2007-06-30, file Enc-03-02.mpp)

Last finish 2008-06-25 → 2008-04-24 (-62d).

Changed:

| ID | Task | Start | Finish | Total float | Predecessors | Other |
| --- | --- | --- | --- | --- | --- | --- |
| 1 | koncepce vybavení místnosti | 2008-04-04 → 2008-03-31 (-4d) | 2008-04-09 → 2008-04-03 (-6d) |  |  |  |
| 2 | rozpočet vybavení místnosti | 2008-04-08 → 2008-04-02 (-6d) | 2008-04-09 → 2008-04-03 (-6d) |  |  |  |
| 3 | schválení koncepce a rozpočtu vybavení | 2008-04-10 → 2008-04-04 (-6d) | 2008-04-10 → 2008-04-04 (-6d) |  |  |  |
| 4 | výběr a objednání počítačů | 2008-04-11 → 2008-04-07 (-4d) | 2008-04-15 → 2008-04-09 (-6d) | 10d → 0d |  |  |
| 5 | dodání počítačů a dataprojektoru | 2008-04-30 → 2008-04-24 (-6d) | 2008-04-30 → 2008-04-24 (-6d) | 10d → 0d |  |  |
| 6 | zazdění dveří | 2008-04-11 → 2008-04-07 (-4d) | 2008-04-14 → 2008-04-08 (-6d) | 11d → 9d |  |  |
| 7 | podhled | 2008-04-15 → 2008-04-09 (-6d) | 2008-04-16 → 2008-04-10 (-6d) | 11d → 9d |  |  |
| 8 | elektroinstalace | 2008-04-17 → 2008-04-11 (-6d) | 2008-04-17 → 2008-04-11 (-6d) | 11d → 9d |  |  |
| 9 | vymalování | 2008-04-18 → 2008-03-31 (-18d) | 2008-04-18 → 2008-03-31 (-18d) | 11d → 18d | 8 → none |  |
| 10 | položení koberce | 2008-04-21 → 2008-03-31 (-21d) | 2008-04-21 → 2008-03-31 (-21d) | 11d → 18d | 9 → none |  |
| 11 | výběr a objednání nábytku | 2008-04-11 → 2008-03-31 (-11d) | 2008-04-15 → 2008-04-02 (-13d) | 0d → 16d | 3 → none |  |
| 12 | dodání a montáž nábytku | 2008-05-09 → 2008-03-31 (-39d) | 2008-05-09 → 2008-03-31 (-39d) | 0d → 18d | 10, 11FS+3w → none |  |
| 13 | vyvětrání | 2008-05-09 → 2008-03-31 (-39d) | 2008-05-14 → 2008-04-05 (-39d) | 4.88d → 58.12d | 12 → none |  |
| 14 | instalace sítě | 2008-05-15 → 2008-03-31 (-45d) | 2008-05-15 → 2008-03-31 (-45d) | 1d → 18d | 13 → none |  |
| 15 | instalace počítačů | 2008-05-16 → 2008-03-31 (-46d) | 2008-05-16 → 2008-03-31 (-46d) | 1d → 18d | 14, 5 → none |  |
| 16 | příprava rezervačního software | 2008-04-04 → 2008-03-31 (-4d) | 2008-04-10 → 2008-04-04 (-6d) | 25d → 14d |  |  |
| 17 | zahájení provozu místnosti | 2008-05-16 → 2008-03-31 (-46d) | 2008-05-16 → 2008-03-31 (-46d) | 1d → 19d | 16, 15 → none |  |
| 18 | webová prezentace uvedení | 2008-05-19 → 2008-03-31 (-49d) | 2008-05-20 → 2008-04-01 (-49d) | 1d → 17d | 17 → none |  |
| 19 | přihlašování na uvedení | 2008-06-03 → 2008-03-31 (-64d) | 2008-06-18 → 2008-04-15 (-64d) | 4.88d → 28.12d | 18FS+2w → none |  |
| 20 | objednání občerstvení | 2008-04-11 → 2008-03-31 (-11d) | 2008-04-11 → 2008-03-31 (-11d) | 39d → 18d | 3 → none |  |
| 21 | návrh letáků k uvedení | 2008-04-11 → 2008-03-31 (-11d) | 2008-04-14 → 2008-04-01 (-13d) | 40d → 17d | 3 → none |  |
| 22 | dodání letáků | 2008-04-14 → 2008-03-31 (-14d) | 2008-04-14 → 2008-03-31 (-14d) | 40d → 19d | 21 → none |  |
| 23 | rozeslání pozvánek | 2008-04-15 → 2008-03-31 (-15d) | 2008-04-16 → 2008-04-01 (-15d) | 47d → 17d | 22 → none |  |
| 24 | výběr, objednání propagačních materiálů | 2008-04-11 → 2008-03-31 (-11d) | 2008-04-11 → 2008-03-31 (-11d) | 39d → 18d | 3 → none |  |
| 25 | dodání propagačních materiálů | 2008-04-11 → 2008-03-31 (-11d) | 2008-04-11 → 2008-03-31 (-11d) | 39d → 19d | 24 → none |  |
| 26 | milník přípravy akce uvedení | 2008-04-18 → 2008-03-31 (-18d) | 2008-04-18 → 2008-03-31 (-18d) | 39d → 19d | 25FS+5d, 22FS+3d → none |  |
| 27 | uzávěrka přihlašování | 2008-06-18 → 2008-03-31 (-79d) | 2008-06-18 → 2008-03-31 (-79d) | 1d → 19d | 19 → none |  |
| 28 | průběh akce uvedení software | 2008-06-24 → 2008-03-31 (-85d) | 2008-06-24 → 2008-03-31 (-85d) | 0d → 18d | 26FS+1w, 20FS+10d, 27FS+2d → none | constraint must start on 2008-06-24 → none |
| 29 | tisková zpráva o uvedení | 2008-06-25 → 2008-03-31 (-86d) | 2008-06-25 → 2008-03-31 (-86d) | 0d → 18d | 28, 23 → none |  |

## Version 4 (saved 2007-06-30, file Enc-03-04.mpp)

Last finish 2008-04-24 → 2008-06-25 (+62d).

Changed:

| ID | Task | Start | Finish | Total float | Predecessors | Other |
| --- | --- | --- | --- | --- | --- | --- |
| 1 | koncepce vybavení místnosti | 2008-03-31 → 2008-04-04 (+4d) | 2008-04-03 → 2008-04-09 (+6d) |  |  |  |
| 2 | rozpočet vybavení místnosti | 2008-04-02 → 2008-04-08 (+6d) | 2008-04-03 → 2008-04-09 (+6d) |  |  |  |
| 3 | schválení koncepce a rozpočtu vybavení | 2008-04-04 → 2008-04-10 (+6d) | 2008-04-04 → 2008-04-10 (+6d) |  |  |  |
| 4 | výběr a objednání počítačů | 2008-04-07 → 2008-04-11 (+4d) | 2008-04-09 → 2008-04-15 (+6d) | 0d → 10d |  |  |
| 5 | dodání počítačů a dataprojektoru | 2008-04-24 → 2008-04-30 (+6d) | 2008-04-24 → 2008-04-30 (+6d) | 0d → 10d |  |  |
| 6 | zazdění dveří | 2008-04-07 → 2008-04-11 (+4d) | 2008-04-08 → 2008-04-14 (+6d) | 9d → 8d |  |  |
| 7 | podhled | 2008-04-09 → 2008-04-15 (+6d) | 2008-04-10 → 2008-04-16 (+6d) | 9d → 8d |  |  |
| 8 | elektroinstalace | 2008-04-11 → 2008-04-17 (+6d) | 2008-04-11 → 2008-04-17 (+6d) | 9d → 8d |  |  |
| 9 | vymalování | 2008-03-31 → 2008-04-18 (+18d) | 2008-03-31 → 2008-04-18 (+18d) | 18d → 8d | none → 8 | constraint none → finish no later than 2008-04-30 |
| 10 | položení koberce | 2008-03-31 → 2008-04-21 (+21d) | 2008-03-31 → 2008-04-21 (+21d) | 18d → 11d | none → 9 |  |
| 11 | výběr a objednání nábytku | 2008-03-31 → 2008-04-11 (+11d) | 2008-04-02 → 2008-04-15 (+13d) | 16d → 0d | none → 3 |  |
| 12 | dodání a montáž nábytku | 2008-03-31 → 2008-05-09 (+39d) | 2008-03-31 → 2008-05-09 (+39d) | 18d → 0d | none → 10, 11FS+3w |  |
| 13 | vyvětrání | 2008-03-31 → 2008-05-09 (+39d) | 2008-04-05 → 2008-05-14 (+39d) | 58.12d → 4.88d | none → 12 |  |
| 14 | instalace sítě | 2008-03-31 → 2008-05-15 (+45d) | 2008-03-31 → 2008-05-15 (+45d) | 18d → 1d | none → 13 |  |
| 15 | instalace počítačů | 2008-03-31 → 2008-05-16 (+46d) | 2008-03-31 → 2008-05-16 (+46d) | 18d → 1d | none → 14, 5 |  |
| 16 | příprava rezervačního software | 2008-03-31 → 2008-04-04 (+4d) | 2008-04-04 → 2008-04-10 (+6d) | 14d → 25d |  |  |
| 17 | zahájení provozu místnosti | 2008-03-31 → 2008-05-16 (+46d) | 2008-03-31 → 2008-05-16 (+46d) | 19d → 1d | none → 16, 15 |  |
| 18 | webová prezentace uvedení | 2008-03-31 → 2008-05-19 (+49d) | 2008-04-01 → 2008-05-20 (+49d) | 17d → 1d | none → 17 |  |
| 19 | přihlašování na uvedení | 2008-03-31 → 2008-06-03 (+64d) | 2008-04-15 → 2008-06-18 (+64d) | 28.12d → 4.88d | none → 18FS+2w |  |
| 20 | objednání občerstvení | 2008-03-31 → 2008-04-11 (+11d) | 2008-03-31 → 2008-04-11 (+11d) | 18d → 39d | none → 3 |  |
| 21 | návrh letáků k uvedení | 2008-03-31 → 2008-04-11 (+11d) | 2008-04-01 → 2008-04-14 (+13d) | 17d → 40d | none → 3 |  |
| 22 | dodání letáků | 2008-03-31 → 2008-04-14 (+14d) | 2008-03-31 → 2008-04-14 (+14d) | 19d → 40d | none → 21 |  |
| 23 | rozeslání pozvánek | 2008-03-31 → 2008-04-15 (+15d) | 2008-04-01 → 2008-04-16 (+15d) | 17d → 47d | none → 22 |  |
| 24 | výběr, objednání propagačních materiálů | 2008-03-31 → 2008-04-11 (+11d) | 2008-03-31 → 2008-04-11 (+11d) | 18d → 39d | none → 3 |  |
| 25 | dodání propagačních materiálů | 2008-03-31 → 2008-04-11 (+11d) | 2008-03-31 → 2008-04-11 (+11d) | 19d → 39d | none → 24 |  |
| 26 | milník přípravy akce uvedení | 2008-03-31 → 2008-04-18 (+18d) | 2008-03-31 → 2008-04-18 (+18d) | 19d → 39d | none → 25FS+5d, 22FS+3d |  |
| 27 | uzávěrka přihlašování | 2008-03-31 → 2008-06-18 (+79d) | 2008-03-31 → 2008-06-18 (+79d) | 19d → 1d | none → 19 |  |
| 28 | průběh akce uvedení software | 2008-03-31 → 2008-06-24 (+85d) | 2008-03-31 → 2008-06-24 (+85d) | 18d → 0d | none → 26FS+1w, 20FS+10d, 27FS+2d | constraint none → must start on 2008-06-24 |
| 29 | tisková zpráva o uvedení | 2008-03-31 → 2008-06-25 (+86d) | 2008-03-31 → 2008-06-25 (+86d) | 18d → 0d | none → 28, 23 |  |

## Version 5 (saved 2007-06-30, file Enc-03-05.mpp)

Last finish stays 2008-06-25.

Changed:

| ID | Task | Start | Finish | Total float | Other |
| --- | --- | --- | --- | --- | --- |
| 10 | položení koberce | 2008-04-21 → 2008-05-05 (+14d) | 2008-04-21 → 2008-05-05 (+14d) | 11d → 0d | constraint none → as late as possible |
| 16 | příprava rezervačního software |  | 2008-04-10 → 2008-04-15 (+5d) | 25d → 20.38d | resources none → Kolínská |

## Version 6 (saved 2007-06-30, file Enc-03-08.mpp)

Last finish stays 2008-06-25.

Added:

| ID | Task | Duration | Start | Finish | Constraint |
| --- | --- | --- | --- | --- | --- |
| 1 | **rekonstrukce zasedací místnosti** | 29d | 2008-04-04 | 2008-05-16 |  |
| 19 | **akce uvedení nového software na trh** | 52d | 2008-04-11 | 2008-06-25 |  |
| 32 | **porada vedení** | 44d | 2008-04-11 | 2008-06-13 |  |
| 33 | porada vedení 1 | 1d | 2008-04-11 | 2008-04-11 | start no earlier than 2008-04-11 |
| 34 | porada vedení 2 | 1d | 2008-05-12 | 2008-05-12 | start no earlier than 2008-05-09 |
| 35 | porada vedení 3 | 1d | 2008-06-13 | 2008-06-13 | start no earlier than 2008-06-13 |

## Version 7 (saved 2007-06-30, file Enc-03-06.mpp)

Last finish stays 2008-06-25.

Removed: 32 porada vedení; 33 porada vedení 1; 34 porada vedení 2; 35 porada vedení 3

## Version 8 (saved 2007-06-30, file Enc-03-09.mpp)

Last finish stays 2008-06-25.

Added:

| ID | Task | Duration | Start | Finish | Constraint |
| --- | --- | --- | --- | --- | --- |
| 32 | **porada vedení** | 44d | 2008-04-11 | 2008-06-13 |  |
| 33 | porada vedení 1 | 1d | 2008-04-11 | 2008-04-11 | start no earlier than 2008-04-11 |
| 34 | porada vedení 2 | 1d | 2008-05-12 | 2008-05-12 | start no earlier than 2008-05-09 |
| 35 | porada vedení 3 | 1d | 2008-06-13 | 2008-06-13 | start no earlier than 2008-06-13 |

## Version 9 (saved 2007-06-30, file Enc-04-01.mpp)

Last finish stays 2008-06-25.

Changed:

| ID | Task | Start | Total float | Other |
| --- | --- | --- | --- | --- |
| 1 | **rekonstrukce zasedací místnosti** |  |  | resources none → papír [0%]; toner [0%]; telefon [0%] |
| 2 | koncepce vybavení místnosti |  |  | resources Kolínská; údržbář 1 → Kolínská [50%]; údržbáři [50%] |
| 3 | rozpočet vybavení místnosti |  |  | resources none → Sladká |
| 4 | schválení koncepce a rozpočtu vybavení |  |  | resources none → Novák [25%] |
| 5 | výběr a objednání počítačů |  | 10d → 10.12d | resources none → Kolínská [25%] |
| 6 | dodání počítačů a dataprojektoru | 2008-04-30 → 2008-04-29 (-1d) | 10d → 10.12d | resources none → Kolínská [25%] |
| 7 | zazdění dveří |  |  | resources none → zedníci [50%] |
| 8 | podhled |  |  | resources none → údržbáři [200%] |
| 9 | elektroinstalace |  |  | resources none → údržbáři [200%] |
| 10 | vymalování |  |  | resources none → malíři [200%] |
| 11 | položení koberce |  |  | resources none → údržbáři [50%]; koberec [92 m2] |
| 12 | výběr a objednání nábytku |  |  | resources none → Sladká [50%] |
| 15 | instalace sítě |  |  | resources none → Kolínská; síťový kabel [45 m.] |
| 16 | instalace počítačů |  | 1d → 0d | resources none → Kolínská |
| 17 | příprava rezervačního software |  |  | resources Kolínská → Kolínská [25%]; Janda [25%] |

## Version 10 (saved 2007-06-30, file Enc-03-10.mpp)

Last finish stays 2008-06-25.

Changed:

| ID | Task | Start | Total float | Other |
| --- | --- | --- | --- | --- |
| 1 | **rekonstrukce zasedací místnosti** |  |  | resources papír [0%]; toner [0%]; telefon [0%] → none |
| 2 | koncepce vybavení místnosti |  |  | resources Kolínská [50%]; údržbáři [50%] → Kolínská; údržbář 1 |
| 3 | rozpočet vybavení místnosti |  |  | resources Sladká → none |
| 4 | schválení koncepce a rozpočtu vybavení |  |  | resources Novák [25%] → none |
| 5 | výběr a objednání počítačů |  | 10.12d → 10d | resources Kolínská [25%] → none |
| 6 | dodání počítačů a dataprojektoru | 2008-04-29 → 2008-04-30 (+1d) | 10.12d → 10d | resources Kolínská [25%] → none |
| 7 | zazdění dveří |  |  | resources zedníci [50%] → none |
| 8 | podhled |  |  | resources údržbáři [200%] → none |
| 9 | elektroinstalace |  |  | resources údržbáři [200%] → none |
| 10 | vymalování |  |  | resources malíři [200%] → none |
| 11 | položení koberce |  |  | resources údržbáři [50%]; koberec [92 m2] → none |
| 12 | výběr a objednání nábytku |  |  | resources Sladká [50%] → none |
| 15 | instalace sítě |  |  | resources Kolínská; síťový kabel [45 m.] → none |
| 16 | instalace počítačů |  | 0d → 1d | resources Kolínská → none |
| 17 | příprava rezervačního software |  |  | resources Kolínská [25%]; Janda [25%] → Kolínská |

## Version 11 (saved 2007-06-30, file Enc-04-02.mpp)

Last finish stays 2008-06-25.

Changed:

| ID | Task | Start | Total float | Other |
| --- | --- | --- | --- | --- |
| 1 | **rekonstrukce zasedací místnosti** |  |  | resources none → papír [0%]; toner [0%]; telefon [0%] |
| 2 | koncepce vybavení místnosti |  |  | resources Kolínská; údržbář 1 → Kolínská [50%]; údržbáři [50%] |
| 3 | rozpočet vybavení místnosti |  |  | resources none → Sladká |
| 4 | schválení koncepce a rozpočtu vybavení |  |  | resources none → Novák [25%] |
| 5 | výběr a objednání počítačů |  | 10d → 10.12d | resources none → Kolínská [25%] |
| 6 | dodání počítačů a dataprojektoru | 2008-04-30 → 2008-04-29 (-1d) | 10d → 10.12d | resources none → Kolínská [25%] |
| 7 | zazdění dveří |  |  | resources none → zedníci [50%] |
| 8 | podhled |  |  | resources none → údržbáři [200%] |
| 9 | elektroinstalace |  |  | resources none → údržbáři [200%] |
| 10 | vymalování |  |  | resources none → malíři [200%] |
| 11 | položení koberce |  |  | resources none → údržbáři [50%]; koberec [92 m2] |
| 12 | výběr a objednání nábytku |  |  | resources none → Sladká [50%] |
| 15 | instalace sítě |  |  | resources none → Kolínská; síťový kabel [45 m.] |
| 16 | instalace počítačů |  | 1d → 0d | resources none → Kolínská |
| 17 | příprava rezervačního software |  |  | resources Kolínská → Kolínská [25%]; Janda [25%] |
| 19 | **akce uvedení nového software na trh** |  |  | resources none → papír [0%]; toner [0%]; telefon [0%] |
| 20 | webová prezentace uvedení | 2008-05-19 → 2008-05-17 (-2d) |  | resources none → Kolínská [50%] |
| 22 | objednání občerstvení |  |  | resources none → Sladká [25%] |
| 23 | návrh letáků k uvedení |  |  | resources none → Smetana [50%] |
| 25 | rozeslání pozvánek |  |  | resources none → Sladká; rozeslání pozvánky [100 ks] |
| 26 | výběr, objednání propagačních materiálů |  |  | resources none → Sladká |
| 30 | průběh akce uvedení software |  |  | resources none → Novák; Kolínská; Sladká; občerstvení [6.2%] |
| 31 | tisková zpráva o uvedení |  |  | resources none → Novák [25%] |
| 33 | porada vedení 1 |  |  | resources none → občerstvení [0.1%]; Novák [25%]; Sladká [25%]; Dvořák [25%]; Benešová [25%]; Janda [25%]; Kolínská [25%] |
| 34 | porada vedení 2 |  |  | resources none → občerstvení [0.1%]; Novák [25%]; Sladká [25%]; Dvořák [25%]; Smetana [25%]; Benešová [25%]; Janda [25%]; Kolínská [25%] |
| 35 | porada vedení 3 |  |  | resources none → občerstvení [0.1%]; Novák [25%]; Sladká [25%]; Dvořák [25%]; Smetana [25%]; Benešová [25%]; Janda [25%]; Kolínská [25%] |

## Version 12 (saved 2007-06-30, file Enc-04-06.mpp)

Last finish stays 2008-06-25.

Changed:

| ID | Task | Start | Finish | Duration | Total float |
| --- | --- | --- | --- | --- | --- |
| 1 | **rekonstrukce zasedací místnosti** | 2008-04-04 → 2008-04-07 (+3d) |  | 29d → 28d |  |
| 2 | koncepce vybavení místnosti | 2008-04-04 → 2008-04-07 (+3d) | 2008-04-09 → 2008-04-10 (+1d) |  |  |
| 3 | rozpočet vybavení místnosti | 2008-04-08 → 2008-04-09 (+1d) | 2008-04-09 → 2008-04-10 (+1d) |  |  |
| 4 | schválení koncepce a rozpočtu vybavení | 2008-04-10 → 2008-04-11 (+1d) | 2008-04-10 → 2008-04-11 (+1d) |  |  |
| 5 | výběr a objednání počítačů | 2008-04-11 → 2008-04-14 (+3d) | 2008-04-15 → 2008-04-16 (+1d) |  | 10.12d → 9.25d |
| 6 | dodání počítačů a dataprojektoru | 2008-04-29 → 2008-04-30 (+1d) | 2008-04-30 → 2008-05-05 (+5d) |  | 10.12d → 8.38d |
| 7 | zazdění dveří | 2008-04-11 → 2008-04-14 (+3d) | 2008-04-14 → 2008-04-15 (+1d) |  | 8d → 7d |
| 8 | podhled | 2008-04-15 → 2008-04-16 (+1d) | 2008-04-16 → 2008-04-17 (+1d) |  | 8d → 7d |
| 9 | elektroinstalace | 2008-04-17 → 2008-04-18 (+1d) | 2008-04-17 → 2008-04-18 (+1d) |  | 8d → 7d |
| 10 | vymalování | 2008-04-18 → 2008-04-21 (+3d) | 2008-04-18 → 2008-04-21 (+3d) |  | 8d → 7d |
| 12 | výběr a objednání nábytku | 2008-04-11 → 2008-04-14 (+3d) |  | 3d → 2d |  |
| 17 | příprava rezervačního software | 2008-04-04 → 2008-04-07 (+3d) | 2008-04-15 → 2008-04-11 (-4d) |  | 20.38d → 22d |
| 19 | **akce uvedení nového software na trh** | 2008-04-11 → 2008-04-14 (+3d) |  | 52d → 51d |  |
| 22 | objednání občerstvení | 2008-04-11 → 2008-04-14 (+3d) | 2008-04-11 → 2008-04-14 (+3d) |  | 39d → 38d |
| 23 | návrh letáků k uvedení | 2008-04-11 → 2008-04-17 (+6d) | 2008-04-14 → 2008-04-18 (+4d) |  | 40d → 36d |
| 24 | dodání letáků | 2008-04-14 → 2008-04-18 (+4d) | 2008-04-14 → 2008-04-18 (+4d) |  | 40d → 36d |
| 25 | rozeslání pozvánek | 2008-04-15 → 2008-04-22 (+7d) | 2008-04-16 → 2008-04-23 (+7d) |  | 47d → 42d |
| 26 | výběr, objednání propagačních materiálů | 2008-04-11 → 2008-04-21 (+10d) | 2008-04-11 → 2008-04-21 (+10d) |  | 39d → 33d |
| 27 | dodání propagačních materiálů | 2008-04-11 → 2008-04-21 (+10d) | 2008-04-11 → 2008-04-21 (+10d) |  | 39d → 33d |
| 28 | milník přípravy akce uvedení | 2008-04-18 → 2008-04-28 (+10d) | 2008-04-18 → 2008-04-28 (+10d) |  | 39d → 33d |

## Version 13 (saved 2007-06-30, file Enc-04-04.mpp)

Last finish stays 2008-06-25.

Changed:

| ID | Task | Start | Finish | Duration | Total float |
| --- | --- | --- | --- | --- | --- |
| 1 | **rekonstrukce zasedací místnosti** | 2008-04-07 → 2008-04-04 (-3d) |  | 28d → 29d |  |
| 2 | koncepce vybavení místnosti | 2008-04-07 → 2008-04-04 (-3d) | 2008-04-10 → 2008-04-09 (-1d) |  |  |
| 3 | rozpočet vybavení místnosti | 2008-04-09 → 2008-04-08 (-1d) | 2008-04-10 → 2008-04-09 (-1d) |  |  |
| 4 | schválení koncepce a rozpočtu vybavení | 2008-04-11 → 2008-04-10 (-1d) | 2008-04-11 → 2008-04-10 (-1d) |  |  |
| 5 | výběr a objednání počítačů | 2008-04-14 → 2008-04-11 (-3d) | 2008-04-16 → 2008-04-15 (-1d) |  | 9.25d → 10.12d |
| 6 | dodání počítačů a dataprojektoru | 2008-04-30 → 2008-04-29 (-1d) | 2008-05-05 → 2008-04-30 (-5d) |  | 8.38d → 10.12d |
| 7 | zazdění dveří | 2008-04-14 → 2008-04-11 (-3d) | 2008-04-15 → 2008-04-14 (-1d) |  | 7d → 8d |
| 8 | podhled | 2008-04-16 → 2008-04-15 (-1d) | 2008-04-17 → 2008-04-16 (-1d) |  | 7d → 8d |
| 9 | elektroinstalace | 2008-04-18 → 2008-04-17 (-1d) | 2008-04-18 → 2008-04-17 (-1d) |  | 7d → 8d |
| 10 | vymalování | 2008-04-21 → 2008-04-18 (-3d) | 2008-04-21 → 2008-04-18 (-3d) |  | 7d → 8d |
| 12 | výběr a objednání nábytku | 2008-04-14 → 2008-04-11 (-3d) |  | 2d → 3d |  |
| 17 | příprava rezervačního software | 2008-04-07 → 2008-04-04 (-3d) | 2008-04-11 → 2008-04-15 (+4d) |  | 22d → 20.38d |
| 19 | **akce uvedení nového software na trh** | 2008-04-14 → 2008-04-11 (-3d) |  | 51d → 52d |  |
| 22 | objednání občerstvení | 2008-04-14 → 2008-04-11 (-3d) | 2008-04-14 → 2008-04-11 (-3d) |  | 38d → 39d |
| 23 | návrh letáků k uvedení | 2008-04-17 → 2008-04-14 (-3d) | 2008-04-18 → 2008-04-15 (-3d) |  | 36d → 39d |
| 24 | dodání letáků | 2008-04-18 → 2008-04-15 (-3d) | 2008-04-18 → 2008-04-15 (-3d) |  | 36d → 39d |
| 25 | rozeslání pozvánek | 2008-04-22 → 2008-04-17 (-5d) | 2008-04-23 → 2008-04-18 (-5d) |  | 42d → 45d |
| 26 | výběr, objednání propagačních materiálů | 2008-04-21 → 2008-04-16 (-5d) | 2008-04-21 → 2008-04-16 (-5d) |  | 33d → 36d |
| 27 | dodání propagačních materiálů | 2008-04-21 → 2008-04-16 (-5d) | 2008-04-21 → 2008-04-16 (-5d) |  | 33d → 36d |
| 28 | milník přípravy akce uvedení | 2008-04-28 → 2008-04-23 (-5d) | 2008-04-28 → 2008-04-23 (-5d) |  | 33d → 36d |

## Version 14 (saved 2007-06-30, file Enc-04-05.mpp)

Last finish stays 2008-06-25.

Changed:

| ID | Task | Start | Finish | Duration | Total float |
| --- | --- | --- | --- | --- | --- |
| 1 | **rekonstrukce zasedací místnosti** | 2008-04-04 → 2008-04-07 (+3d) |  | 29d → 28d |  |
| 2 | koncepce vybavení místnosti | 2008-04-04 → 2008-04-07 (+3d) | 2008-04-09 → 2008-04-10 (+1d) |  |  |
| 3 | rozpočet vybavení místnosti | 2008-04-08 → 2008-04-09 (+1d) | 2008-04-09 → 2008-04-10 (+1d) |  |  |
| 4 | schválení koncepce a rozpočtu vybavení | 2008-04-10 → 2008-04-11 (+1d) | 2008-04-10 → 2008-04-11 (+1d) |  |  |
| 5 | výběr a objednání počítačů | 2008-04-11 → 2008-04-14 (+3d) | 2008-04-15 → 2008-04-16 (+1d) |  | 10.12d → 9.25d |
| 6 | dodání počítačů a dataprojektoru | 2008-04-29 → 2008-04-30 (+1d) | 2008-04-30 → 2008-05-05 (+5d) |  | 10.12d → 8.38d |
| 7 | zazdění dveří | 2008-04-11 → 2008-04-14 (+3d) | 2008-04-14 → 2008-04-15 (+1d) |  | 8d → 7d |
| 8 | podhled | 2008-04-15 → 2008-04-16 (+1d) | 2008-04-16 → 2008-04-17 (+1d) |  | 8d → 7d |
| 9 | elektroinstalace | 2008-04-17 → 2008-04-18 (+1d) | 2008-04-17 → 2008-04-18 (+1d) |  | 8d → 7d |
| 10 | vymalování | 2008-04-18 → 2008-04-21 (+3d) | 2008-04-18 → 2008-04-21 (+3d) |  | 8d → 7d |
| 12 | výběr a objednání nábytku | 2008-04-11 → 2008-04-14 (+3d) |  | 3d → 2d |  |
| 17 | příprava rezervačního software | 2008-04-04 → 2008-04-07 (+3d) | 2008-04-15 → 2008-04-16 (+1d) |  | 20.38d → 19.38d |
| 19 | **akce uvedení nového software na trh** | 2008-04-11 → 2008-04-14 (+3d) |  | 52d → 51d |  |
| 22 | objednání občerstvení | 2008-04-11 → 2008-04-14 (+3d) | 2008-04-11 → 2008-04-14 (+3d) |  | 39d → 38d |
| 23 | návrh letáků k uvedení | 2008-04-14 → 2008-04-17 (+3d) | 2008-04-15 → 2008-04-18 (+3d) |  | 39d → 36d |
| 24 | dodání letáků | 2008-04-15 → 2008-04-18 (+3d) | 2008-04-15 → 2008-04-18 (+3d) |  | 39d → 36d |
| 25 | rozeslání pozvánek | 2008-04-17 → 2008-04-22 (+5d) | 2008-04-18 → 2008-04-23 (+5d) |  | 45d → 42d |
| 26 | výběr, objednání propagačních materiálů | 2008-04-16 → 2008-04-21 (+5d) | 2008-04-16 → 2008-04-21 (+5d) |  | 36d → 33d |
| 27 | dodání propagačních materiálů | 2008-04-16 → 2008-04-21 (+5d) | 2008-04-16 → 2008-04-21 (+5d) |  | 36d → 33d |
| 28 | milník přípravy akce uvedení | 2008-04-23 → 2008-04-28 (+5d) | 2008-04-23 → 2008-04-28 (+5d) |  | 36d → 33d |

## Version 15 (saved 2007-07-02, file Enc-04-07.mpp)

Last finish stays 2008-06-25.

Changed:

| ID | Task | Finish | Total float |
| --- | --- | --- | --- |
| 17 | příprava rezervačního software | 2008-04-16 → 2008-04-11 (-5d) | 19.38d → 22d |

## Version 16 (saved 2007-07-02, file Enc-06-02.mpp)

Last finish stays 2008-06-25.

Changed:

| ID | Task | Start | Finish | Duration | Total float | Other |
| --- | --- | --- | --- | --- | --- | --- |
| 1 | **rekonstrukce zasedací místnosti** |  |  |  |  | baseline start none → 2008-04-07; baseline finish none → 2008-05-16 |
| 2 | koncepce vybavení místnosti |  |  |  |  | baseline start none → 2008-04-07; baseline finish none → 2008-04-10 |
| 3 | rozpočet vybavení místnosti |  |  |  |  | baseline start none → 2008-04-09; baseline finish none → 2008-04-10 |
| 4 | schválení koncepce a rozpočtu vybavení |  |  |  |  | baseline start none → 2008-04-11; baseline finish none → 2008-04-11 |
| 5 | výběr a objednání počítačů |  |  |  |  | baseline start none → 2008-04-14; baseline finish none → 2008-04-16 |
| 6 | dodání počítačů a dataprojektoru |  |  |  |  | baseline start none → 2008-04-30; baseline finish none → 2008-05-05 |
| 7 | zazdění dveří |  | 2008-04-15 → 2008-04-14 (-1d) | 2d → 1d | 7d → 8d | baseline start none → 2008-04-14; baseline finish none → 2008-04-15 |
| 8 | podhled | 2008-04-16 → 2008-04-15 (-1d) | 2008-04-17 → 2008-04-16 (-1d) |  | 7d → 8d | baseline start none → 2008-04-16; baseline finish none → 2008-04-17 |
| 9 | elektroinstalace | 2008-04-18 → 2008-04-17 (-1d) | 2008-04-18 → 2008-04-17 (-1d) |  | 7d → 8d | baseline start none → 2008-04-18; baseline finish none → 2008-04-18 |
| 10 | vymalování | 2008-04-21 → 2008-04-18 (-3d) | 2008-04-21 → 2008-04-18 (-3d) |  | 7d → 8d | baseline start none → 2008-04-21; baseline finish none → 2008-04-21 |
| 11 | položení koberce |  |  |  |  | baseline start none → 2008-05-05; baseline finish none → 2008-05-05 |
| 12 | výběr a objednání nábytku |  |  |  |  | baseline start none → 2008-04-14; baseline finish none → 2008-04-15 |
| 13 | dodání a montáž nábytku |  |  |  |  | baseline start none → 2008-05-09; baseline finish none → 2008-05-09 |
| 14 | vyvětrání |  |  |  |  | baseline start none → 2008-05-09; baseline finish none → 2008-05-14 |
| 15 | instalace sítě |  |  |  |  | baseline start none → 2008-05-15; baseline finish none → 2008-05-15 |
| 16 | instalace počítačů |  |  |  |  | baseline start none → 2008-05-16; baseline finish none → 2008-05-16 |
| 17 | příprava rezervačního software |  |  |  |  | baseline start none → 2008-04-07; baseline finish none → 2008-04-11 |
| 18 | zahájení provozu místnosti |  |  |  |  | baseline start none → 2008-05-16; baseline finish none → 2008-05-16 |
| 19 | **akce uvedení nového software na trh** |  |  |  |  | baseline start none → 2008-04-14; baseline finish none → 2008-06-25 |
| 20 | webová prezentace uvedení |  |  |  |  | baseline start none → 2008-05-17; baseline finish none → 2008-05-20 |
| 21 | přihlašování na uvedení |  |  |  |  | baseline start none → 2008-06-03; baseline finish none → 2008-06-18 |
| 22 | objednání občerstvení |  |  |  |  | baseline start none → 2008-04-14; baseline finish none → 2008-04-14 |
| 23 | návrh letáků k uvedení |  |  |  |  | baseline start none → 2008-04-17; baseline finish none → 2008-04-18 |
| 24 | dodání letáků |  |  |  |  | baseline start none → 2008-04-18; baseline finish none → 2008-04-18 |
| 25 | rozeslání pozvánek |  |  |  |  | baseline start none → 2008-04-22; baseline finish none → 2008-04-23 |
| 26 | výběr, objednání propagačních materiálů |  |  |  |  | baseline start none → 2008-04-21; baseline finish none → 2008-04-21 |
| 27 | dodání propagačních materiálů |  |  |  |  | baseline start none → 2008-04-21; baseline finish none → 2008-04-21 |
| 28 | milník přípravy akce uvedení |  |  |  |  | baseline start none → 2008-04-28; baseline finish none → 2008-04-28 |
| 29 | uzávěrka přihlašování |  |  |  |  | baseline start none → 2008-06-18; baseline finish none → 2008-06-18 |
| 30 | průběh akce uvedení software |  |  |  |  | baseline start none → 2008-06-24; baseline finish none → 2008-06-24 |
| 31 | tisková zpráva o uvedení |  |  |  |  | baseline start none → 2008-06-25; baseline finish none → 2008-06-25 |
| 32 | **porada vedení** |  |  |  |  | baseline start none → 2008-04-11; baseline finish none → 2008-06-13 |
| 33 | porada vedení 1 |  |  |  |  | baseline start none → 2008-04-11; baseline finish none → 2008-04-11 |
| 34 | porada vedení 2 |  |  |  |  | baseline start none → 2008-05-12; baseline finish none → 2008-05-12 |
| 35 | porada vedení 3 |  |  |  |  | baseline start none → 2008-06-13; baseline finish none → 2008-06-13 |

## Version 17 (saved 2007-07-02, file Enc-06-01.mpp)

Last finish stays 2008-06-25.

Changed:

| ID | Task | Start | Finish | Duration | Total float |
| --- | --- | --- | --- | --- | --- |
| 7 | zazdění dveří |  | 2008-04-14 → 2008-04-15 (+1d) | 1d → 2d | 8d → 7d |
| 8 | podhled | 2008-04-15 → 2008-04-16 (+1d) | 2008-04-16 → 2008-04-17 (+1d) |  | 8d → 7d |
| 9 | elektroinstalace | 2008-04-17 → 2008-04-18 (+1d) | 2008-04-17 → 2008-04-18 (+1d) |  | 8d → 7d |
| 10 | vymalování | 2008-04-18 → 2008-04-21 (+3d) | 2008-04-18 → 2008-04-21 (+3d) |  | 8d → 7d |

## Version 18 (data date 2008-04-15, saved 2007-07-02, file Enc-06-04.mpp)

Last finish stays 2008-06-25. Complete tasks 0 → 8.

Changed:

| ID | Task | Start | Finish | Duration | Complete | Total float |
| --- | --- | --- | --- | --- | --- | --- |
| 1 | **rekonstrukce zasedací místnosti** | 2008-04-07 A |  |  | 0% → 43% | 0d → 1d |
| 2 | koncepce vybavení místnosti | 2008-04-07 A | 2008-04-10 A |  | 0% → 100% | 0d → none |
| 3 | rozpočet vybavení místnosti | 2008-04-09 A | 2008-04-10 A |  | 0% → 100% | 0d → none |
| 4 | schválení koncepce a rozpočtu vybavení | 2008-04-11 A | 2008-04-11 A |  | 0% → 100% | 0d → none |
| 5 | výběr a objednání počítačů | 2008-04-14 A |  |  | 0% → 71% |  |
| 7 | zazdění dveří | 2008-04-14 A | 2008-04-15 → 2008-04-14 A (-1d) | 2d → 1d | 0% → 100% | 7d → none |
| 8 | podhled | 2008-04-16 → 2008-04-15 A (-1d) | 2008-04-17 → 2008-04-16 (-1d) |  | 0% → 25% | 7d → 8d |
| 9 | elektroinstalace | 2008-04-18 → 2008-04-17 (-1d) | 2008-04-18 → 2008-04-17 (-1d) |  |  | 7d → 8d |
| 10 | vymalování | 2008-04-21 → 2008-04-18 (-3d) | 2008-04-21 → 2008-04-18 (-3d) |  |  | 7d → 8d |
| 12 | výběr a objednání nábytku | 2008-04-14 A | 2008-04-15 A |  | 0% → 100% | 0d → none |
| 17 | příprava rezervačního software | 2008-04-07 A | 2008-04-11 A |  | 0% → 100% | 22d → none |
| 19 | **akce uvedení nového software na trh** | 2008-04-14 A |  |  | 0% → 2% |  |
| 22 | objednání občerstvení | 2008-04-14 A | 2008-04-14 A |  | 0% → 100% | 38d → none |
| 32 | **porada vedení** | 2008-04-11 A |  |  | 0% → 33% |  |
| 33 | porada vedení 1 | 2008-04-11 A | 2008-04-11 A |  | 0% → 100% | 51d → none |

## Version 19 (data date 2008-04-15, saved 2007-07-02, file Enc-06-03.mpp)

Last finish stays 2008-06-25.

Changed:

| ID | Task | Complete |
| --- | --- | --- |
| 1 | **rekonstrukce zasedací místnosti** | 43% → 44% |
| 8 | podhled | 25% → 50% |

## Version 20 (data date 2008-04-15, saved 2007-07-02, file Enc-06-05.mpp)

Last finish stays 2008-06-25.

Changed:

| ID | Task | Start | Finish | Complete | Total float |
| --- | --- | --- | --- | --- | --- |
| 1 | **rekonstrukce zasedací místnosti** |  |  | 44% → 43% |  |
| 8 | podhled |  |  | 50% → 25% |  |
| 22 | objednání občerstvení | 2008-04-14 A → 2008-04-21 A (+7d) | 2008-04-14 A → 2008-04-21 A (+7d) |  |  |
| 23 | návrh letáků k uvedení | 2008-04-17 → 2008-04-14 (-3d) | 2008-04-18 → 2008-04-15 (-3d) |  | 36d → 39d |
| 24 | dodání letáků | 2008-04-18 → 2008-04-15 (-3d) | 2008-04-18 → 2008-04-15 (-3d) |  | 36d → 39d |
| 25 | rozeslání pozvánek | 2008-04-22 → 2008-04-17 (-5d) | 2008-04-23 → 2008-04-18 (-5d) |  | 42d → 45d |
| 26 | výběr, objednání propagačních materiálů | 2008-04-21 → 2008-04-16 (-5d) | 2008-04-21 → 2008-04-16 (-5d) |  | 33d → 36d |
| 27 | dodání propagačních materiálů | 2008-04-21 → 2008-04-16 (-5d) | 2008-04-21 → 2008-04-16 (-5d) |  | 33d → 36d |
| 28 | milník přípravy akce uvedení | 2008-04-28 → 2008-04-23 (-5d) | 2008-04-28 → 2008-04-23 (-5d) |  | 33d → 36d |

## Version 21 (data date 2008-05-31, saved 2007-07-02, file Enc-06-06.mpp)

Last finish stays 2008-06-25. Complete tasks 8 → 27.

Changed:

| ID | Task | Start | Finish | Duration | Complete | Total float | Other |
| --- | --- | --- | --- | --- | --- | --- | --- |
| 1 | **rekonstrukce zasedací místnosti** |  | 2008-05-16 A |  | 43% → 100% | 1d → none |  |
| 5 | výběr a objednání počítačů |  | 2008-04-16 A |  | 71% → 100% | 9.25d → none |  |
| 6 | dodání počítačů a dataprojektoru | 2008-04-30 → 2008-05-14 A (+14d) | 2008-05-05 → 2008-05-14 A (+9d) |  | 0% → 100% | 8.38d → none | constraint none → start no earlier than 2008-05-12 |
| 8 | podhled |  | 2008-04-16 A |  | 25% → 100% | 8d → none |  |
| 9 | elektroinstalace | 2008-04-17 A | 2008-04-17 A |  | 0% → 100% | 8d → none |  |
| 10 | vymalování | 2008-04-18 A | 2008-04-18 A |  | 0% → 100% | 8d → none |  |
| 11 | položení koberce | 2008-05-05 A | 2008-05-05 A |  | 0% → 100% | 0d → none |  |
| 13 | dodání a montáž nábytku | 2008-05-09 A | 2008-05-09 A |  | 0% → 100% | 0d → none |  |
| 14 | vyvětrání | 2008-05-09 A | 2008-05-14 A |  | 0% → 100% | 4.88d → none |  |
| 15 | instalace sítě | 2008-05-15 A | 2008-05-15 A |  | 0% → 100% | 1d → none |  |
| 16 | instalace počítačů | 2008-05-16 A | 2008-05-16 A |  | 0% → 100% | 0d → none |  |
| 18 | zahájení provozu místnosti | 2008-05-16 A | 2008-05-16 A |  | 0% → 100% | 1d → none |  |
| 19 | **akce uvedení nového software na trh** |  |  |  | 2% → 15% |  |  |
| 20 | webová prezentace uvedení | 2008-05-17 A | 2008-05-20 A |  | 0% → 100% | 1d → none |  |
| 21 | přihlašování na uvedení | 2008-06-03 → 2008-06-04 A (+1d) | 2008-06-18 → 2008-06-19 (+1d) |  |  | 4.88d → 1.88d |  |
| 23 | návrh letáků k uvedení | 2008-04-14 A | 2008-04-15 A |  | 0% → 100% | 39d → none |  |
| 24 | dodání letáků | 2008-04-15 A | 2008-04-15 A |  | 0% → 100% | 39d → none |  |
| 25 | rozeslání pozvánek | 2008-04-17 A | 2008-04-18 A |  | 0% → 100% | 45d → none |  |
| 26 | výběr, objednání propagačních materiálů | 2008-04-16 A | 2008-04-16 A |  | 0% → 100% | 36d → none |  |
| 27 | dodání propagačních materiálů | 2008-04-16 A | 2008-04-16 A |  | 0% → 100% | 36d → none |  |
| 28 | milník přípravy akce uvedení | 2008-04-23 A | 2008-04-23 A |  | 0% → 100% | 36d → none |  |
| 29 | uzávěrka přihlašování | 2008-06-18 → 2008-06-19 (+1d) | 2008-06-18 → 2008-06-19 (+1d) |  |  | 1d → 0d |  |
| 30 | průběh akce uvedení software |  |  |  |  |  | resources Novák; Kolínská; Sladká; občerstvení [6.2%] → Novák; Kolínská; Sladká |
| 32 | **porada vedení** |  | 2008-06-13 → 2008-06-16 (+3d) | 44d → 45d | 33% → 67% | 8d → 7d |  |
| 33 | porada vedení 1 |  |  |  |  |  | resources občerstvení [0.1%]; Novák [25%]; Sladká [25%]; Dvořák [25%]; Benešová [25%]; Janda [25%]; Kolínská [25%] → Novák [25%]; Sladká [25%]; Dvořák [25%]; Benešová [25%]; Janda [25%]; Kolínská [25%] |
| 34 | porada vedení 2 | 2008-05-12 A | 2008-05-12 A |  | 0% → 100% | 32d → none | resources občerstvení [0.1%]; Novák [25%]; Sladká [25%]; Dvořák [25%]; Smetana [25%]; Benešová [25%]; Janda [25%]; Kolínská [25%] → Novák [25%]; Sladká [25%]; Dvořák [25%]; Smetana [25%]; Benešová [25%]; Janda [25%]; Kolínská [25%] |
| 35 | porada vedení 3 | 2008-06-13 → 2008-06-16 A (+3d) | 2008-06-13 → 2008-06-16 (+3d) |  |  | 8d → 7d | resources občerstvení [0.1%]; Novák [25%]; Sladká [25%]; Dvořák [25%]; Smetana [25%]; Benešová [25%]; Janda [25%]; Kolínská [25%] → Novák [25%]; Sladká [25%]; Dvořák [25%]; Smetana [25%]; Benešová [25%]; Janda [25%]; Kolínská [25%] |

## Version 22 (data date 2008-06-25, saved 2007-07-02, file Enc-06-07.mpp)

Last finish stays 2008-06-25. Complete tasks 27 → 32.

Changed:

| ID | Task | Start | Finish | Complete | Total float |
| --- | --- | --- | --- | --- | --- |
| 19 | **akce uvedení nového software na trh** |  | 2008-06-25 A | 15% → 100% | 0d → none |
| 21 | přihlašování na uvedení |  | 2008-06-19 A | 0% → 100% | 1.88d → none |
| 29 | uzávěrka přihlašování | 2008-06-19 A | 2008-06-19 A | 0% → 100% | 0d → none |
| 30 | průběh akce uvedení software | 2008-06-24 A | 2008-06-24 A | 0% → 100% | 0d → none |
| 31 | tisková zpráva o uvedení | 2008-06-25 A | 2008-06-25 A | 0% → 100% | 0d → none |
| 32 | **porada vedení** |  | 2008-06-16 A | 67% → 100% | 7d → none |
| 35 | porada vedení 3 |  | 2008-06-16 A | 0% → 100% | 7d → none |
